# Proyecto1_s

Schedule from MS Project, 2012-10-08 to 2013-12-09.
Microsoft

## Calendars

- Estándar: Mon-Fri 09:00-13:00, 15:00-19:00; Sat-Sun off.

## Resources

| Resource | Rate | Cost per use |
| --- | --- | --- |
| gerente general | 35000 |  |
| gerente Marketing | 30000 |  |
| gerente Tecnologia | 30000 |  |
| gerente Recursos humanos | 30000 |  |
| Ingeniero desarrollo_1 | 18750 |  |
| Ingeniero desarrollo_2 | 18750 |  |
| Jefe_desarrollo y comunicaciones_2 | 25000 |  |
| Jefe_nuevos productos | 25000 |  |
| Profesional Soporte Nivel II_1 | 15625 |  |
| Profesional Certificacion_1 | 15625 |  |
| Profesional Certificacion_2 | 15625 |  |
| Profesional Marketing | 15625 |  |
| Profesional_RecursosHumanos | 15625 |  |
| Profesionales_6 | 15625 |  |
| Profesionales_7 | 15625 |  |
| Lider_Tecnico_1 | 13750 |  |
| Lideres_Desarrollo | 13750 |  |
| Analistas Soporte_1 | 11250 |  |
| Analistas Soporte_2 | 11250 |  |
| Analistas Soporte_3 | 11250 |  |
| Analistas Soporte_4 | 11250 |  |
| Analistas Desarrollo_1 | 11250 |  |
| Analistas Desarrollo_2 | 11250 |  |
| Analistas Desarrollo_3 | 11250 |  |
| Analistas Desarrollo_4 |  |  |
| Jefe Soporte | 25000 |  |
| Jefe_desarrollo y comunicaciones | 25000 |  |
| Jefe_nuevos productos_2 | 25000 |  |
| Cuadrilla_1 |  | 5000000 |
| Cuadrilla_2 |  | 5000000 |
| Cuadrilla_3 |  | 5000000 |
| Lider_Tecnico_2 | 13750 |  |
| Profesional Soporte Nivel II_2 | 15625 |  |
| Ing. De soporte |  |  |
| Supervisor NOC |  |  |
| Gerente de Proyecto |  |  |
| líder LAN |  |  |
| Líder Mesa de Ayuda |  |  |
| Líder WAN |  |  |
| Profesional en Logística |  |  |
| Ingeniero LAN |  |  |
| Ingeniero WAN |  |  |

## Schedule

| ID | WBS | Task | Type | Duration | Start | Finish | Predecessors | Total slack | Work |
| --- | --- | --- | --- | --- | --- | --- | --- | --- | --- |
| 1 | 1 | **Proyecto NFC** |  | 306d | 2012-10-08 | 2013-12-09 |  | 0d | 8h |
| 2 | 1.1 | **Formulacion, Diseño y Evaluación** |  | 10d | 2012-10-08 | 2012-10-19 |  | 0d |  |
| 3 | 1.1.1 | Conceptualización de la solución |  | 2d | 2012-10-08 | 2012-10-09 |  | 0d |  |
| 4 | 1.1.2 | Ingeniería conceptual |  | 2d | 2012-10-10 | 2012-10-11 | 3 | 0d |  |
| 5 | 1.1.3 | Ingeniería Básica |  | 2d | 2012-10-12 | 2012-10-15 | 4 | 0d |  |
| 6 | 1.1.4 | Ingeniería de Detalle |  | 2d | 2012-10-16 | 2012-10-17 | 5 | 0d |  |
| 7 | 1.1.5 | Propuesta formal |  | 2d | 2012-10-18 | 2012-10-19 | 6 | 0d |  |
| 8 | 1.1.6 | Firma de contrato | milestone | 0d | 2012-10-19 | 2012-10-19 | 7 | 0d |  |
| 9 | 1.2 | **Ejecucion** |  | 34d | 2012-10-22 | 2012-12-06 |  | 0d |  |
| 10 | 1.2.1 | **Registradoras** |  | 34d | 2012-10-22 | 2012-12-06 |  | 0d |  |
| 11 | 1.2.1.1 | Solicitud de registradoras con tecnologia NFC |  | 4d | 2012-10-22 | 2012-10-25 | 8 | 0d |  |
| 12 | 1.2.1.2 | Entrega de Registradoras por parte de Proveedor | milestone | 0d | 2012-10-25 | 2012-10-25 | 11 | 0d |  |
| 13 | 1.2.1.3 | Set de Pruebas para muestra de registradoras recibidos |  | 2d | 2012-10-26 | 2012-10-29 | 12 | 0d |  |
| 14 | 1.2.1.4 | Pruebas Registradoras OK | milestone | 0d | 2012-10-29 | 2012-10-29 | 13 | 0d |  |
| 15 | 1.2.1.5 | Parametrización, registros y Configuración de Registradoras |  | 3d | 2012-10-30 | 2012-11-01 | 14 | 0d |  |
| 16 | 1.2.1.6 | Finalizacion de Adecuación de Registradoras | milestone | 0d | 2012-11-01 | 2012-11-01 | 15 | 287d |  |
| 17 | 1.2.1.7 | Distribución, instalación y capacitación en sitio de 80 talanqueras en las estaciones o portales que defina el cliente |  | 20d | 2012-11-02 | 2012-11-29 | 15 | 0d |  |
| 18 | 1.2.1.8 | Finalizacion de instalación y capactiación en Sedes | milestone | 0d | 2012-11-29 | 2012-11-29 | 17 | 0d |  |
| 19 | 1.2.1.9 | Pruebas en Linea de Registradoras |  | 2d | 2012-11-30 | 2012-12-03 | 18 | 0d |  |
| 20 | 1.2.1.10 | Finalización de Pruebas | milestone | 0d | 2012-12-03 | 2012-12-03 | 19 | 0d |  |
| 21 | 1.2.1.11 | Parametrización Final de Registradora |  | 1d | 2012-12-04 | 2012-12-04 | 20 | 0d |  |
| 22 | 1.2.1.12 | Finalizacion de Paraetrización | milestone | 0d | 2012-12-04 | 2012-12-04 | 21 | 0d |  |
| 23 | 1.2.1.13 | Transacción efectiva |  | 1d | 2012-12-05 | 2012-12-05 | 22 | 0d |  |
| 24 | 1.2.1.14 | Finalización Transaccion Efectiva | milestone | 0d | 2012-12-05 | 2012-12-05 | 23 | 0d |  |
| 25 | 1.2.1.15 | Aprobación puesta en servicio por parte de cliente |  | 1d | 2012-12-06 | 2012-12-06 | 24 | 0d |  |
| 26 | 1.2.1.16 | Finalización Aprobación puesta en servicio | milestone | 0d | 2012-12-06 | 2012-12-06 | 25 | 0d |  |

| ID | WBS | Task | Type | Duration | Start | Finish | Predecessors | Total slack | Free slack |
| --- | --- | --- | --- | --- | --- | --- | --- | --- | --- |
| 27 | 1.2.2 | **Webservice y Software Administración** |  | 24d | 2012-10-22 | 2012-11-22 |  | 10d |  |
| 28 | 1.2.2.1 | Efectuar calculos de transaccionabilidad |  | 2d | 2012-10-29 | 2012-10-30 | 37 | 10d | 0d |
| 29 | 1.2.2.2 | Finalizacion de calculos Transaccionabilidad | milestone | 0d | 2012-10-30 | 2012-10-30 | 28 | 10d | 0d |
| 30 | 1.2.2.3 | Adecuación de Servidores y instalación de Hardware Adicional requerido |  | 4d | 2012-10-31 | 2012-11-05 | 29 | 10d | 0d |
| 31 | 1.2.2.4 | Finalización de adecuación y instalación de nuevo Hardware | milestone | 0d | 2012-11-05 | 2012-11-05 | 30 | 10d | 0d |
| 32 | 1.2.2.5 | Pruebas de Software Internas |  | 3d | 2012-11-06 | 2012-11-08 | 31 | 10d | 0d |
| 33 | 1.2.2.6 | Finalización de Pruebas Software | milestone | 0d | 2012-11-08 | 2012-11-08 | 32 | 10d | 0d |
| 34 | 1.2.2.7 | Configuración y parametrización de usuarios para acceso a WebService |  | 2d | 2012-10-22 | 2012-10-23 | 8 | 10d | 0d |
| 35 | 1.2.2.8 | Finalizacion de configruación de nuevo Usuario | milestone | 0d | 2012-10-23 | 2012-10-23 | 34 | 10d | 0d |
| 36 | 1.2.2.9 | Configuración de Formularios y Usuarios para acceso a Software |  | 3d | 2012-10-24 | 2012-10-26 | 35 | 10d | 0d |
| 37 | 1.2.2.10 | Configuración Software Finalizada | milestone | 0d | 2012-10-26 | 2012-10-26 | 36 | 10d | 0d |
| 38 | 1.2.2.11 | Prueba de transacción |  | 3d | 2012-11-09 | 2012-11-13 | 33 | 10d | 0d |
| 39 | 1.2.2.12 | Finalización Prueba Transaccion | milestone | 0d | 2012-11-13 | 2012-11-13 | 38 | 10d | 0d |
| 40 | 1.2.2.13 | Aprobación Arranque |  | 2d | 2012-11-14 | 2012-11-15 | 39 | 10d | 0d |
| 41 | 1.2.2.14 | Finalización Aprobación Arranque | milestone | 0d | 2012-11-15 | 2012-11-15 | 40 | 10d | 0d |
| 42 | 1.2.2.15 | Pruebas Finales con cliente |  | 4d | 2012-11-16 | 2012-11-21 | 41 | 10d | 0d |
| 43 | 1.2.2.16 | Finalización pruebas cliente | milestone | 0d | 2012-11-21 | 2012-11-21 | 42 | 10d | 0d |
| 44 | 1.2.2.17 | Aprobación puesta en servicio |  | 1d | 2012-11-22 | 2012-11-22 | 43 | 10d | 0d |
| 45 | 1.2.2.18 | Finalización Aprobación puesta en servicio | milestone | 0d | 2012-11-22 | 2012-11-22 | 44 | 10d |  |
| 46 | 1.3 | **Seguimiento y control** |  | 44d | 2012-10-22 | 2012-12-20 |  | 252d |  |
| 47 | 1.3.1 | Seguimiento y control |  | 44d | 2012-10-22 | 2012-12-20 | 8 | 252d |  |
| 48 | 1.3.2 | Documentación de avances |  | 3d | 2012-10-25 | 2012-10-29 | 8, 50 | 290d |  |
| 49 | 1.3.3 | Reunión de seguimiento |  | 5d | 2012-10-22 | 2012-10-26 | 8 | 291d |  |
| 50 | 1.3.4 | Entrega de documentos |  | 3d | 2012-10-22 | 2012-10-24 | 8 | 290d | 0d |

| ID | WBS | Task | Type | Duration | Start | Finish | Predecessors | Total slack | Constraint | Resources | Work |
| --- | --- | --- | --- | --- | --- | --- | --- | --- | --- | --- | --- |
| 51 | 1.4 | **Operación** |  | 261d | 2012-12-07 | 2013-12-07 |  | 0d |  |  |  |
| 52 | 1.4.1 | 5.1. Monitoreo y soporte | manual | 262d | 2012-12-07 | 2013-12-07 | 26, 45 |  | finish no earlier than 2013-12-14 |  |  |
| 53 | 1.4.2 | 5.2. Supervisión y seguimiento de SLAs | manual | 262d | 2012-12-07 | 2013-12-07 | 26, 45 |  |  |  |  |
| 54 | 1.5 | **Cierre** |  | 1d | 2013-12-09 | 2013-12-09 |  | 0d |  |  | 8h |
| 55 | 1.5.1 | Reunión de cierre de contrato con el cliente |  | 1d | 2013-12-09 | 2013-12-09 | 52, 53 | 0d |  | Gerente de Proyecto | 8h |
| 56 | 1.5.2 | Cierre de contrato | milestone | 0d | 2013-12-09 | 2013-12-09 | 55 | 0d |  | Gerente de Proyecto |  |
